Schedule from MS Project, 2010-02-01 to 2010-04-27.
TOSHIBA

## Calendars

- Standard: Mon-Fri 08:00-12:00, 13:00-17:00; Sat-Sun off.

## Resources

| Resource | Group |
| --- | --- |
| Ралица Тодорова | Софтуерен инженер |
| Надежда Апостолова | QA |
| Иван Пушкаров | Бизнес анализатор |
| Станимира Железова | Специалист по бази от данни |
| Пламен Геров | Дизайнер |
| Боян Киров | Мениджър на проекта |
| Георги Бинев | Специалист по бази от данни |
| Антон Илиев | Софтуерен инженер |
| Климентина Русева | QA |
| Дарина Евтимова | Софтуерен инженер |

## Schedule

| ID | WBS | Task | Duration | Start | Finish | Predecessors | Total slack | Free slack | Constraint | Resources | Work |
| --- | --- | --- | --- | --- | --- | --- | --- | --- | --- | --- | --- |
| 1 | B | Начало | 0.17d | 2010-02-01 | 2010-02-01 |  | 0d |  | start no earlier than 2010-02-01 |  |  |
| 2 | DB | **Схема на базата от данни** | 13.58d? | 2010-02-01 | 2010-02-18 | 1 | 0d |  |  |  | 170.67h |
| 3 | DB1 | **Анализ на съществуващата система** | 3.5d? | 2010-02-01 | 2010-02-04 |  | 0d |  |  |  | 53.33h |
| 4 | DB1.1 | Анализ на клиентската част | 3.5d? | 2010-02-01 | 2010-02-04 |  | 0d |  |  | Иван Пушкаров [50%]; Ралица Тодорова [50%] | 28h |
| 5 | DB1.2 | Анализ на базата от данни | 1.58d? | 2010-02-01 | 2010-02-02 |  | 1.92d |  |  | Иван Пушкаров [50%]; Ралица Тодорова [50%]; Станимира Железова | 25.33h |
| 6 | DB2 | **Създаване на модел** | 3.08d? | 2010-02-04 | 2010-02-09 | 3 | 0d |  |  |  | 49.33h |
| 7 | DB2.1 | Създаване на E/R модел | 1.58d? | 2010-02-04 | 2010-02-08 |  | 0d |  |  | Станимира Железова; Георги Бинев | 25.33h |
| 8 | DB2.2 | Създаване на релационен модел | 1.5d? | 2010-02-08 | 2010-02-09 | 7 | 0d |  |  | Станимира Железова; Георги Бинев | 24h |
| 9 | DB3 | **Създаване на базата от данни** | 2.83d? | 2010-02-09 | 2010-02-12 | 6 | 0d |  |  |  | 22.67h |
| 10 | DB3.1 | Генериране на скрипт за създаване на базата от данни | 1d? | 2010-02-09 | 2010-02-10 |  | 0d |  |  | Георги Бинев | 8h |
| 11 | DB3.2 | Тестване на скрипта за създаване на базата от данни | 1.83d? | 2010-02-10 | 2010-02-12 | 10 | 0d |  |  | Станимира Железова | 14.67h |
| 12 | DB4 | **Документиране** | 4.17d? | 2010-02-12 | 2010-02-18 | 9 | 0d |  |  |  | 45.33h |
| 13 | DB4.1 | Наръчник на потребителя | 2.67d? | 2010-02-16 | 2010-02-18 | 14 | 0d |  |  | Иван Пушкаров | 21.33h |
| 14 | DB4.2 | Документация | 1.5d? | 2010-02-12 | 2010-02-16 |  | 0d |  |  | Георги Бинев; Станимира Железова | 24h |
| 15 | CI | **Интерфейс за комуникация със системата за отчитане на продажбите** | 10d? | 2010-02-18 | 2010-03-04 | 2 | 0d |  |  |  | 164.8h |
| 16 | CI2 | **Създаване на интерфейса** | 7d? | 2010-02-18 | 2010-03-01 |  | 0d |  |  |  | 112h |
| 17 | CI2.1 | Описание на интерфейса | 3.42d? | 2010-02-18 | 2010-02-24 |  | 0d |  |  | Ралица Тодорова [50%]; Дарина Евтимова; Антон Илиев | 54.67h |
| 18 | CI2.2 | Реализация на класове, имплементиращи интерфейса | 3.58d? | 2010-02-24 | 2010-03-01 | 17 | 0d |  |  | Антон Илиев; Дарина Евтимова | 57.33h |
| 19 | CI3 | Тестване на интерфейса за комуникация | 3d? | 2010-03-01 | 2010-03-04 | 16 | 0d |  |  | Климентина Русева; Надежда Апостолова | 48h |
| 20 | CI4 | Документация | 0.3d? | 2010-03-01 | 2010-03-02 | 16 | 2.7d |  |  | Антон Илиев; Дарина Евтимова | 4.8h |
| 21 | MS | **Модул за управление на складовите наличности** | 17.46d? | 2010-03-04 | 2010-03-30 | 15 | 0d |  |  |  | 308h |
| 22 | MS1 | Анализ на изискванията | 3.63d? | 2010-03-04 | 2010-03-10 |  | 0d |  |  | Иван Пушкаров; Ралица Тодорова | 49.33h |
| 23 | MS2 | **Създаване на потребителски интерфейс** | 4.5d? | 2010-03-10 | 2010-03-16 | 22 | 5.5d |  |  |  | 36h |
| 24 | MS2.1 | Форма за въвеждане и корекция на поръчки за доставки | 2.17d? | 2010-03-11 | 2010-03-15 | 25 | 5.5d | 0d |  | Пламен Геров | 17.33h |
| 25 | MS2.2 | Форма за проверка на наличности | 1.17d? | 2010-03-10 | 2010-03-11 |  | 5.5d | 0d |  | Пламен Геров | 9.33h |
| 26 | MS2.3 | Форма за изготвяне на график за приемане на доставки | 1.17d? | 2010-03-15 | 2010-03-16 | 24 | 5.5d |  |  | Пламен Геров | 9.33h |

| ID | WBS | Task | Duration | Start | Finish | Predecessors | Total slack | Free slack | Resources | Work |
| --- | --- | --- | --- | --- | --- | --- | --- | --- | --- | --- |
| 27 | MS3 | **Създаване на бизнес логика** | 10d? | 2010-03-10 | 2010-03-24 | 22 | 0d |  |  | 106.67h |
| 28 | MS3.1 | **Създаване на пакети с процедури в базата от данни** | 6.67d? | 2010-03-10 | 2010-03-19 |  | 0d |  |  | 53.33h |
| 29 | MS3.1.1 | Пакет за проверка на наличностите | 2.17d? | 2010-03-11 | 2010-03-15 | 31 | 0d |  | Георги Бинев | 17.33h |
| 30 | MS3.1.2 | Пакет за обработка на данните за доставките | 3.33d? | 2010-03-15 | 2010-03-19 | 29 | 0d |  | Георги Бинев | 26.67h |
| 31 | MS3.1.3 | Пакет за извличане на данните за доставките | 1.17d? | 2010-03-10 | 2010-03-11 |  | 0d |  | Георги Бинев | 9.33h |
| 32 | MS3.2 | Създаване на бизнес компоненти | 3.33d? | 2010-03-19 | 2010-03-24 | 28 | 0d |  | Антон Илиев; Дарина Евтимова | 53.33h |
| 33 | MS4 | Тестване на модула за управление на складовите наличности | 3.42d? | 2010-03-24 | 2010-03-29 | 23, 27 | 0.42d |  | Климентина Русева; Надежда Апостолова | 54.67h |
| 34 | MS5 | **Документиране** | 3.83d? | 2010-03-24 | 2010-03-30 | 27, 23 | 0d |  |  | 61.33h |
| 35 | MS5.1 | Наръчник на потребителя | 2.17d? | 2010-03-26 | 2010-03-30 | 36 | 0d |  | Иван Пушкаров; Пламен Геров | 34.67h |
| 36 | MS5.2 | Документация | 1.67d? | 2010-03-24 | 2010-03-26 |  | 0d |  | Георги Бинев; Дарина Евтимова | 26.67h |
| 37 | ME | **Модул за служители** | 21.81d? | 2010-02-18 | 2010-03-22 | 2 | 5.65d |  |  | 346.67h |
| 38 | ME1 | Анализ на изискванията | 5d? | 2010-02-18 | 2010-02-25 |  | 5.65d | 0d | Иван Пушкаров; Ралица Тодорова [50%] | 40h |
| 39 | ME2 | **Създаване на потребителски интерфейс** | 6.5d? | 2010-02-25 | 2010-03-08 | 38 | 11.96d | 6.31d |  | 52h |
| 40 | ME2.1 | Форма за въвеждане и корекция на данните за служителите | 1.33d? | 2010-02-25 | 2010-03-01 |  | 11.96d | 0d | Пламен Геров | 10.67h |
| 41 | ME2.2 | Форма за въвеждане на критерий за изготвяне на график | 2.17d? | 2010-03-01 | 2010-03-03 | 40 | 11.96d | 0d | Пламен Геров | 17.33h |
| 42 | ME2.3 | Форма за извеждане и редактиране на изготвения график | 3d | 2010-03-03 | 2010-03-08 | 41 | 11.96d |  | Пламен Геров | 24h |
| 43 | ME3 | **Създаване на бизнес логиката** | 12.81d? | 2010-02-25 | 2010-03-16 | 38 | 5.65d | 0d |  | 138.67h |
| 44 | ME3.1 | **Създаване на пакети с процедури в базата от данни** | 4.33d? | 2010-02-25 | 2010-03-04 |  | 5.65d | 0d |  | 34.67h |
| 45 | ME3.1.1 | Пакет за обработка на данните за служителите | 3.17d? | 2010-02-26 | 2010-03-04 | 46 | 5.65d |  | Станимира Железова | 25.33h |
| 46 | ME3.1.2 | Пакет за извличане на данните за служителите | 1.17d? | 2010-02-25 | 2010-02-26 |  | 5.65d | 0d | Станимира Железова | 9.33h |
| 47 | ME3.2 | **Създаване на бизнес компоненти** | 8.48d? | 2010-03-04 | 2010-03-16 | 44 | 5.65d |  |  | 104h |
| 48 | ME3.2.1 | Дизайн и имплементация на алгоритъм за изготвяне на график | 3.48d | 2010-03-11 | 2010-03-16 | 49 | 5.65d |  | Дарина Евтимова; Антон Илиев; Ралица Тодорова | 64h |
| 49 | ME3.2.2 | Изготвяне на йерархия от класове за работа с данните на служителите | 5d? | 2010-03-04 | 2010-03-11 |  | 5.65d | 0d | Дарина Евтимова | 40h |
| 50 | ME4 | Тестване на модула за служителите | 3.25d? | 2010-03-16 | 2010-03-19 | 39, 43 | 6.4d |  | Климентина Русева; Надежда Апостолова | 52h |

| ID | WBS | Task | Duration | Start | Finish | Predecessors | Total slack | Free slack | Resources | Work |
| --- | --- | --- | --- | --- | --- | --- | --- | --- | --- | --- |
| 51 | ME5 | **Документиране** | 4d? | 2010-03-16 | 2010-03-22 | 39, 43 | 5.65d |  |  | 64h |
| 52 | ME5.1 | Наръчник на потребителя | 2d? | 2010-03-18 | 2010-03-22 | 53 | 5.65d |  | Иван Пушкаров; Пламен Геров | 32h |
| 53 | ME5.2 | Документация | 2d? | 2010-03-16 | 2010-03-18 |  | 5.65d | 0d | Станимира Железова; Антон Илиев | 32h |
| 54 | IP | **Инсталационен пакет на системата** | 10.28d? | 2010-03-30 | 2010-04-13 | 37, 21 | 0d |  |  | 162.4h |
| 55 | IP1 | Събиране на необходимите компоненти | 0.92d | 2010-03-30 | 2010-03-31 |  | 0d |  | Ралица Тодорова; Георги Бинев | 14.67h |
| 56 | IP2 | Тестване на системата | 4.92d? | 2010-03-31 | 2010-04-07 | 55 | 0d |  | Климентина Русева; Надежда Апостолова | 78.67h |
| 57 | IP3 | Пакетиране и конфигуриране | 1.67d? | 2010-04-07 | 2010-04-08 | 56 | 0d |  | Антон Илиев; Дарина Евтимова | 26.67h |
| 58 | IP4 | Тестване на инсталационния пакет | 0.92d? | 2010-04-08 | 2010-04-09 | 57 | 0d |  | Климентина Русева; Надежда Апостолова | 14.67h |
| 59 | IP5 | Записване на физически носител | 1d? | 2010-04-09 | 2010-04-12 | 58 | 0.86d |  | Антон Илиев [30%] | 2.4h |
| 60 | IP6 | Документиране | 1.86d? | 2010-04-09 | 2010-04-13 | 58 | 0d |  | Климентина Русева; Антон Илиев [70%] | 25.33h |
| 61 | UM | **Изготвяне на наръчник на потребителя** | 10d? | 2010-04-13 | 2010-04-27 | 54 | 0d |  |  | 80h |
| 62 | UM1 | Обединяване на отделните компоненти | 1.83d? | 2010-04-13 | 2010-04-15 |  | 0d |  | Иван Пушкаров | 14.67h |
| 63 | UM2 | Редактиране | 8.17d? | 2010-04-15 | 2010-04-27 | 62 | 0d |  | Иван Пушкаров | 65.33h |
| 64 | DOC | **Документация** | 7d? | 2010-04-13 | 2010-04-22 | 54 | 3d |  |  | 56h |
| 65 | DOC1 | Обединяване на отделните компоненти | 1.83d? | 2010-04-13 | 2010-04-15 |  | 3d | 0d | Антон Илиев | 14.67h |
| 66 | DOC2 | Редактиране | 5.17d? | 2010-04-15 | 2010-04-22 | 65 | 3d |  | Антон Илиев | 41.33h |
| 67 | E | Край | 0.67d? | 2010-04-26 | 2010-04-27 | 61FF, 64FF | 0d |  |  |  |
